# High Level Plan for SAPBiz 10-22-08 v4

Schedule from MS Project, 2008-09-15 to 2010-01-28, A marks actual dates.
MIT

## Calendars

- Standard: Mon-Fri 08:00-12:00, 13:00-17:00; Sat-Sun off. Exceptions (off unless hours are given): 2008-09-20 to 2008-09-21, 2008-09-27 to 2008-09-28, 2008-10-04 to 2008-10-05, 2008-10-11 to 2008-10-12, 2008-10-18 to 2008-10-19, 2008-10-25 to 2008-10-26, 2008-11-01 to 2008-11-02, 2008-11-08 to 2008-11-09, 2008-11-11, 2008-11-15 to 2008-11-16, 2008-11-22 to 2008-11-23, 2008-11-27 to 2008-11-30, 2008-12-06 to 2008-12-07, 2008-12-13 to 2008-12-14 08:00-12:00, 13:00-17:00, 2008-12-20 to 2008-12-21, 2008-12-25 to 2008-12-28, 2009-01-01 to 2009-01-03.

## Resources

| Resource |
| --- |
| ABAP |
| BO |
| CAO |
| BASIS |
| BA |
| DEV |
| DWH |
| HR-P |
| ALL |
| 20 |
| BUS |
| 8 |
| 7 |
| REP |
| R3 |
| QA |
| FIN |
| LOG |
| EHS |
| HRP |
| IDD |
| ISS |
| R# |
| FQ |
| FI |
| PM |
| B |

## Schedule

| ID | WBS | Task | Type | Duration | Start | Finish | Predecessors | Complete | Remaining | Total slack | Free slack | Constraint | Work |
| --- | --- | --- | --- | --- | --- | --- | --- | --- | --- | --- | --- | --- | --- |
| 1 | 1 | **2009 Support Pack Implementation Project** |  | 70d | 2008-09-15 | 2008-12-23 |  |  |  | 0d |  |  | 2510h |
| 2 | 1.1 | **Project Prep & Planning** |  | 36.5d | 2008-09-15 | 2008-11-04 |  |  |  | 6.75d |  |  | 1568h |
| 3 | 1.1.1 | **Appoint project team, define roles and responsibilities** |  | 1d | 2009-07-01 | 2009-07-01 |  |  |  | 0d |  |  |  |
| 4 | 1.1.1.1 | Appoint project manager |  | 1d? | 2009-08-10 A | 2009-08-10 A |  | 100% |  |  |  |  |  |
| 5 | 1.1.1.2 | Appoint core team |  | 1d? | 2009-08-10 A | 2009-08-10 A |  | 100% |  |  |  |  |  |
| 6 | 1.1.1.3 | Update business owner list with new / changed owners |  | 0.5d | 2009-08-10 A | 2009-08-10 A |  | 100% |  |  |  |  |  |
| 7 | 1.1.2 | **Define high level plan, milestones, deliverables** |  | 1d | 2010-01-15 | 2010-01-15 |  |  |  | 0d |  |  |  |
| 8 | 1.1.2.1 | Determine support packages availability date |  | 0.5d | 2009-08-10 A | 2009-08-10 A |  | 100% |  |  |  |  |  |
| 9 | 1.1.2.2 | Determine desired support package & enhancement package levels |  | 0.5d | 2009-08-10 A | 2009-08-10 A |  | 100% |  |  |  |  |  |
| 10 | 1.1.2.3 | Determine dates for production freeze |  | 0.5d | 2009-08-10 A | 2009-08-10 A |  | 100% |  |  |  |  |  |
| 11 | 1.1.3 | **Define environments, refresh schedule, support pack plan** |  | 1d | 2009-07-01 | 2009-07-01 |  |  |  | 0d |  |  |  |
| 12 | 1.1.3.1 | Identify clients fo Staging, and TST (DEV not refreshed) |  | 0.5d | 2009-08-10 A | 2009-08-10 A |  | 100% |  |  |  |  |  |
| 13 | 1.1.3.2 | Determine production snapshot dates for STG, TST |  | 0.5d | 2009-08-10 A | 2009-08-10 A |  | 100% |  |  |  |  |  |
| 14 | 1.1.3.3 | Determine dates for STG, TST refreshes |  | 0.5d | 2009-08-10 A | 2009-08-10 A |  | 100% |  |  |  |  |  |
| 15 | 1.1.3.4 | Plan datawarehouse extracts |  | 1d? | 2009-07-01 | 2009-07-01 |  |  |  | 0d |  |  |  |
| 16 | 1.1.4 | **Cleanup pending transports** |  | 0d | 2009-08-10 | 2009-08-10 |  |  |  | 63d |  |  |  |
| 17 | 1.1.4.1 | Create transport list |  | 1d | 2009-07-01 A | 2009-07-01 A |  | 100% |  |  |  |  |  |
| 18 | 1.1.4.2 | Determine status and plan for each |  | 5d | 2009-07-01 A | 2009-07-07 | 17 | 25% | 3.75d | 0d |  |  |  |
| 19 | 1.1.4.3 | Execute pending transport plan |  | 60d | 2009-07-01 A | 2009-09-22 |  | 25% | 45d | 0d |  |  |  |
| 20 | 1.1.5 | Upgrade Epi-use |  | 30d | 2009-07-01 | 2009-08-11 |  |  |  | 0d |  |  |  |
| 21 | 1.1.6 | **Test Planning** |  | 31.5d | 2008-09-22 | 2008-11-04 |  |  |  | 1.75d |  |  | 1552h |
| 22 | 1.1.6.1 | **Update test script catalogs** |  | 13d | 2008-09-22 | 2008-10-08 |  |  |  | 1.75d |  |  | 416h |
| 23 | 1.1.6.1.1 | Define, document, communicate test case management procedure - templates, process, … |  | 1d? | 2009-07-01 | 2009-07-01 |  |  |  | 0d |  |  |  |
| 24 | 1.1.6.1.2 | Review transaction / report log for new items |  | 5d | 2008-09-22 | 2008-09-26 |  |  |  | 1.75d | 0d |  |  |
| 25 | 1.1.6.1.3 | Update test script catalog with new transactions / reports |  | 1d | 2008-09-29 | 2008-09-29 | 24 |  |  | 1.75d | 0d |  |  |
| 26 | 1.1.6.1.4 | Review test script catalog for missing / old test scripts |  | 2d | 2008-09-30 | 2008-10-01 | 25 |  |  | 1.75d | 0d |  |  |
| 27 | 1.1.6.1.5 | Create new / update old test scripts |  | 5d | 2008-10-02 | 2008-10-08 | 26 |  |  | 1.75d | 0d |  |  |
| 28 | 1.1.6.1.6 | Convert to new catalog |  | 1d? | 2009-07-01 | 2009-07-01 | 27 |  |  | 0d |  |  |  |
| 29 | 1.1.6.1.7 | Decide what to test in each functional area |  | 1d? | 2009-07-01 | 2009-07-01 | 28 |  |  | 0d |  |  |  |
| 30 | 1.1.6.1.8 | Convert test cases to new template |  | 1d? | 2009-07-01 | 2009-07-01 | 29 |  |  | 0d |  |  |  |
| 31 | 1.1.6.1.9 | Financial Team confirms completeness of test script catalog | milestone | 0d | 2008-10-08 | 2008-10-08 | 30 |  |  | 1.75d |  |  |  |
| 32 | 1.1.6.1.10 | Logistics Team confirms completeness of test script catalog | milestone | 0d | 2008-10-08 | 2008-10-08 | 27 |  |  | 52d |  | start no earlier than 2008-09-20 |  |
| 33 | 1.1.6.1.11 | EHS Team confirms completeness of test script catalog | milestone | 0d | 2008-10-08 | 2008-10-08 | 27 |  |  | 52d |  | start no earlier than 2008-09-20 |  |
| 34 | 1.1.6.1.12 | HR-Payroll Team confirms completeness of test script catalog | milestone | 0d | 2008-10-08 | 2008-10-08 | 27 |  |  | 33.5d | 0d | start no earlier than 2008-09-20 |  |

Notes:
- 1: 2008 plan 2382 hours. Actual / 2009 resource spreadsheet plan 3500 hours, $250K
- 8: 10/15/2009
- 20: Can be done any time before support packs. Ideally 1 month before support pack applied to dev. Provides scrambling in place capability. Won't change refresh requirements and process, but facilitates scrambling process (and time required).

| ID | WBS | Task | Type | Duration | Start | Finish | Predecessors | Complete | Total slack | Free slack | Constraint | Work |
| --- | --- | --- | --- | --- | --- | --- | --- | --- | --- | --- | --- | --- |
| 35 | 1.1.6.2 | **Unit Test Planning** |  | 1.5d | 2008-10-09 | 2008-10-10 |  |  | 33.5d |  |  | 48h |
| 36 | 1.1.6.2.1 | Determine transactions / reports to be tested |  | 1d | 2008-10-09 | 2008-10-09 | 34 |  | 33.5d | 0d |  |  |
| 37 | 1.1.6.2.2 | Update test script catalog |  | 0.5d | 2008-10-10 | 2008-10-10 | 36 |  | 33.5d | 0d |  |  |
| 38 | 1.1.6.3 | **Systems Integration Test Planning** |  | 17d | 2008-10-10 | 2008-11-04 |  |  | 33.5d |  |  | 448h |
| 39 | 1.1.6.3.1 | Define business scenarios |  | 2d | 2008-10-10 | 2008-10-14 | 37 |  | 33.5d | 0d |  |  |
| 40 | 1.1.6.3.2 | Document business scenarios |  | 10d | 2008-10-14 | 2008-10-28 | 39 |  | 33.5d | 0d |  |  |
| 41 | 1.1.6.3.3 | QA review of business scenarios |  | 3d | 2008-10-28 | 2008-10-31 | 40 |  | 33.5d | 0d |  |  |
| 42 | 1.1.6.3.4 | Update business scenarios as required |  | 1d | 2008-10-31 | 2008-11-03 | 41 |  | 33.5d | 0d |  |  |
| 43 | 1.1.6.3.5 | Financial Team confirms completeness of business scenarios | milestone | 0d | 2008-11-03 | 2008-11-03 | 42 |  | 34.5d |  |  |  |
| 44 | 1.1.6.3.6 | Logistics Team confirms completeness of business scenarios | milestone | 0d | 2008-11-03 | 2008-11-03 | 42 |  | 34.5d |  | start no earlier than 2008-09-20 |  |
| 45 | 1.1.6.3.7 | EHS Team confirms completeness of business scenarios | milestone | 0d | 2008-11-03 | 2008-11-03 | 42 |  | 34.5d |  | start no earlier than 2008-09-20 |  |
| 46 | 1.1.6.3.8 | HR-Payroll Team confirms completeness of business scenarios | milestone | 0d | 2008-11-03 | 2008-11-03 | 42 |  | 33.5d | 0d | start no earlier than 2008-09-20 |  |
| 47 | 1.1.6.3.9 | QA confirms completeness of business scenarios |  | 1d | 2008-11-03 | 2008-11-04 | 46 |  | 33.5d |  |  |  |
| 48 | 1.1.6.4 | **User Acceptance Test Planning** |  | 12d | 2008-10-13 | 2008-10-28 |  |  | -0.25d | 0d |  | 152h |
| 49 | 1.1.6.4.1 | Send test script catalog to business owners |  | 0.25d | 2009-08-10 | 2009-08-10 | 31, 6 |  | -1.25d | 0d | start no earlier than 2008-10-14 |  |
| 50 | 1.1.6.4.2 | Business owners select transactions and send back catalogs |  | 10d | 2008-10-13 | 2008-10-24 | 49 |  | -1.25d | 0d | finish no later than 2008-10-24 |  |
| 51 | 1.1.6.4.3 | Business owners define testers and send back list to Team leads |  | 10d | 2008-10-13 | 2008-10-24 | 49 |  | -1.25d | 0d | finish no later than 2008-10-24 |  |
| 52 | 1.1.6.4.4 | Business analysts update test script catalogs |  | 2d | 2008-10-27 | 2008-10-28 | 51 |  | 38d |  |  |  |
| 53 | 1.2 | **System Admin Preparation** |  | 2d | 2008-10-24 | 2008-10-27 |  |  | 39d |  |  | 72h |
| 54 | 1.2.1 | Produce Support Package Notes |  | 1d | 2009-08-10 | 2009-08-10 |  |  | 40d |  |  |  |
| 55 | 1.2.2 | Review and update action log from previous year |  | 2d | 2009-08-10 | 2009-08-11 |  |  | 39d |  |  |  |
| 56 | 1.2.3 | Upgrade Epi-use |  | 1d? | 2009-07-01 | 2009-07-01 |  |  | 0d |  |  |  |
| 57 | 1.2.4 | PS Snapshot for SF3 |  | 1d? | 2009-09-28 A | 2009-09-28 A |  | 100% |  |  | start no earlier than 2009-09-28 |  |
| 58 | 1.2.5 | **SFK Practice update (TBD)** |  | 7d | 2009-10-01 | 2009-10-09 |  |  | 0d |  |  |  |
| 59 | 1.2.5.1 | Test Install Basis Enhancement Pack 1 |  | 7d? | 2009-10-01 | 2009-10-10 |  |  | 0d |  |  |  |
| 60 | 1.2.5.2 | Test Install Enhancement Pack 4 |  | 7d? | 2009-10-01 | 2009-10-10 |  |  | 0d |  | finish no earlier than 2009-10-10 |  |
| 61 | 1.3 | Support packs available from SAP | milestone | 0d | 2009-10-15 | 2009-10-15 |  |  | 10d | 0d | start no earlier than 2009-10-15 |  |

Notes:
- 59: Test process / Resolve issues / Document process / Determine timings
- 60: Test process / Resolve issues / Document process / Determine timings

| ID | WBS | Task | Type | Duration | Start | Finish | Predecessors | Total slack | Free slack | Constraint | Work |
| --- | --- | --- | --- | --- | --- | --- | --- | --- | --- | --- | --- |
| 62 | 1.4 | **SF3 System Refresh** |  | 5d | 2009-10-02 | 2009-10-08 |  | 44d |  |  |  |
| 63 | 1.4.1 | Refresh with 9/28/2009 PS1 Snapshot |  | 2d | 2009-10-02 | 2009-10-05 |  | 44d | 0d |  |  |
| 64 | 1.4.2 | Execute R3 Action Log |  | 0.5d | 2009-10-06 | 2009-10-06 |  | 44d | 0d |  |  |
| 65 | 1.4.3 | Scramble sensitive data |  | 2d | 2009-10-07 | 2009-10-08 |  | 44d |  | finish no earlier than 2009-10-08 |  |
| 66 | 1.5 | PS1 Snapshot for SH2 |  | 1d? | 2009-10-19 | 2009-10-19 |  | 0d |  | start no earlier than 2009-10-19 |  |
| 67 | 1.6 | **SFK Update (Evaluation)** |  | 4d | 2008-10-20 | 2008-10-23 | 61 | 10d |  |  | 20h |
| 68 | 1.6.1 | Apply SAP kernel update |  | 0.5d | 2009-10-19 | 2009-10-19 |  | 10d | 0d | start no earlier than 2009-10-19 |  |
| 69 | 1.6.2 | Upgrade Oracle db |  | 0.5d | 2009-10-20 | 2009-10-20 | 68 | 10d | 0d | start no earlier than 2009-10-20 |  |
| 70 | 1.6.3 | Install Basis Enhancement Pack 1 |  | 1d? | 2009-10-21 | 2009-10-21 | 69 | 0d |  | start no earlier than 2009-10-21 |  |
| 71 | 1.6.4 | Install ECC Enhancement Pack 4 |  | 1d? | 2009-10-22 | 2009-10-22 | 70 | 0d |  | start no earlier than 2009-10-22 |  |
| 72 | 1.6.5 | Import support packages |  | 1d | 2009-10-23 | 2009-10-23 | 71, 61 | 10d | 0d | start no earlier than 2009-10-22 |  |
| 73 | 1.6.6 | Identify and resolve import issues |  | 0.5d | 2009-10-26 | 2009-10-26 | 72 | 10d | 0d | start no earlier than 2009-10-22 |  |
| 74 | 1.6.7 | Validate security infrastructure (SNC) |  | 0.5d | 2009-10-26 | 2009-10-26 | 73 | 10d | 0d | start no earlier than 2009-10-21 |  |
| 75 | 1.6.8 | Validate SAPGui interactions |  | 0.5d | 2009-10-27 | 2009-10-27 | 74 | 10d | 0d | start no earlier than 2009-10-21 |  |
| 76 | 1.6.9 | Validate basic SAP functions work |  | 0.5d | 2009-10-27 | 2009-10-27 | 75 | 10d | 0d | start no earlier than 2009-10-21 |  |
| 77 | 1.7 | **SF3 Update** |  | 3d | 2009-10-26 | 2009-10-28 | 62 | 0d |  |  |  |
| 78 | 1.7.1 | MIT mods, SPAU |  | 3d? | 2009-10-26 | 2009-10-28 |  | 0d |  | finish no earlier than 2009-10-28 |  |
| 79 | 1.8 | **SF2 Update (Development)** |  | 1d | 2008-10-31 | 2009-11-02 |  | 10d |  |  |  |
| 80 | 1.8.1 | Apply SAP kernel update | milestone | 0d | 2009-10-31 | 2009-10-31 |  | 10d | 0d | finish no earlier than 2009-10-31 |  |
| 81 | 1.8.2 | Upgrade Oracle db | milestone | 0d | 2009-10-31 | 2009-10-31 |  | 10d | 0d | finish no earlier than 2009-10-31 |  |
| 82 | 1.8.3 | Install Basis enhancement pack 1 | milestone | 0d? | 2009-11-01 | 2009-11-01 |  | 0d |  | finish no earlier than 2009-11-01 |  |
| 83 | 1.8.4 | Install ECC enhancement pack 4 |  | 1d? | 2009-11-02 | 2009-11-02 |  | 0d |  | start no earlier than 2009-11-01 |  |
| 84 | 1.8.5 | Import support packages |  | 1d | 2009-11-02 | 2009-11-02 |  | 10d | 0d | start no earlier than 2009-11-02 |  |
| 85 | 1.8.6 | Apply BSI Tax Factory Update |  | 0.25d | 2009-11-02 | 2009-11-02 |  | 10d | 0d | start no earlier than 2009-11-02 |  |
| 86 | 1.8.7 | Execute action log (add updates if necessary) |  | 0.5d | 2009-11-02 | 2009-11-02 |  | 10d | 0d | start no earlier than 2009-11-02 |  |
| 87 | 1.8.8 | Import transports from SF3 |  | 0.5d | 2009-11-02 | 2009-11-02 |  | 10d | 0d | start no earlier than 2009-11-02 |  |

Notes:
- 62: The SAP Staging system (SF3) is used for the introduction of SAP notes, SAP problem resolution, and the evaluation of SAP system updates.
- 67: Could this start 10/15 as soon as SP available from SAP?
- 79: 3 days - confirm this can be achieved during SFK updates

| ID | WBS | Task | Type | Duration | Start | Finish | Predecessors | Total slack | Free slack | Constraint |
| --- | --- | --- | --- | --- | --- | --- | --- | --- | --- | --- |
| 88 | 1.9 | **Unit Test Execution in SF2** |  | 5d | 2009-11-02 | 2009-11-08 | 87 | 10d |  |  |
| 89 | 1.9.1 | Financial Unit Tests, Issue identification and retest |  | 5d | 2009-11-02 | 2009-11-08 | 87 | 29d |  | finish no earlier than 2009-11-08 |
| 90 | 1.9.2 | Logistics Unit Tests, Issue identification and retest |  | 5d | 2009-11-02 | 2009-11-08 | 87 | 29d |  | finish no earlier than 2009-11-08 |
| 91 | 1.9.3 | EHS Unit Tests, Issue identification and retest |  | 5d | 2009-11-02 | 2009-11-08 | 87 | 29d |  | finish no earlier than 2009-11-08 |
| 92 | 1.9.4 | HR-Payroll Unit Tests, Issue identification and retest |  | 5d | 2009-11-02 | 2009-11-08 | 87 | 10d | 0d | finish no earlier than 2009-11-08 |
| 93 | 1.9.5 | All functional teams ok environment and move to SIT | milestone | 0d | 2009-11-08 | 2009-11-08 |  | 10d | 0d | start no earlier than 2009-11-08 |
| 94 | 1.10 | SH2 System Refresh |  | 3d? | 2009-11-03 | 2009-11-05 |  | 0d |  | finish no earlier than 2009-11-05 |
| 95 | 1.11 | SH2 Update |  | 1d? | 2009-11-06 | 2009-11-08 |  | 0d |  | finish no earlier than 2009-11-08 |
| 96 | 1.12 | **Execute System Integration Tests in SH2** |  | 10d | 2009-11-09 | 2009-11-22 |  | 10d |  |  |
| 97 | 1.12.1 | Execute System Integration Tests |  | 6d | 2009-11-09 | 2009-11-16 | 126, 93 | 23d |  |  |
| 98 | 1.12.2 | Financial Close |  | 1d | 2009-11-17 | 2009-11-17 | 126, 93 | 23d |  |  |
| 99 | 1.12.3 | Issue Retesting |  | 3d | 2009-11-18 | 2009-11-20 | 126, 93 | 23d |  |  |
| 100 | 1.12.4 | System Integration Test sign-off |  | 1d | 2009-11-23 | 2009-11-23 | 126, 93 | 10d | 0d | finish no earlier than 2009-11-23 |
| 101 | 1.13 | **Execute User Acceptance Test (UAT) in SH2** |  | 13d | 2009-11-23 | 2009-12-09 |  | 8d |  |  |
| 102 | 1.13.1 | Execute UAT |  | 8d | 2009-11-24 | 2009-12-03 | 100 | 10d | 0d | start no earlier than 2009-11-23 |
| 103 | 1.13.2 | Financial Close |  | 2d | 2009-12-03 | 2009-12-04 |  | 10d | 0d |  |
| 104 | 1.13.3 | Issue retesting |  | 3d | 2009-12-07 | 2009-12-09 |  | 10d | 0d |  |
| 105 | 1.13.4 | UAT sign off |  | 1d | 2009-12-10 | 2009-12-10 |  | 7.75d | 0d | start no earlier than 2009-12-10 |
| 106 | 1.14 | **Cutover weekend & Controlled Start** |  | 0.25d | 2009-12-11 | 2009-12-13 | 105 | 7.75d |  |  |
| 107 | 1.14.1 | System message put out on SAP |  | 0.25d | 2009-12-11 | 2009-12-11 |  | 7.75d |  |  |
| 108 | 1.14.2 | System message put out on SAPWeb pages |  | 0.25d | 2009-12-11 | 2009-12-11 |  | 7.75d |  |  |
| 109 | 1.14.3 | Update production (detailed weekend cutover plan in a separate document) |  | 1d? | 2009-12-11 | 2009-12-13 |  | 0d |  |  |
| 110 | 1.14.4 | Production validation | milestone | 0d? | 2009-12-13 | 2009-12-13 |  | 0d |  |  |
| 111 | 1.14.5 | Go/No Go approval | milestone | 0d? | 2009-12-13 | 2009-12-13 |  | 0d |  |  |
| 112 | 1.14.6 | Updated production available |  | 1d? | 2009-12-14 | 2009-12-14 |  | 0d |  | start no earlier than 2009-12-14 |
| 113 | 1.15 | First Calendar 2010 Payroll | milestone | 0d | 2009-12-22 | 2009-12-22 |  | 0d |  | start no earlier than 2009-12-22 |

| ID | WBS | Task | Duration | Start | Finish | Total slack | Free slack | Constraint |
| --- | --- | --- | --- | --- | --- | --- | --- | --- |
| 114 | 1.16 | **Following dates & sequence to be confirmed** | 1d | 2009-07-01 | 2009-07-01 | 0d |  |  |
| 115 | 1.16.1 | SF6 Refresh w/ 10/19/2009 snapshot (no data scrambling) | 3d | 2009-11-02 | 2009-11-04 | 13.25d | 0d | start no earlier than 2009-11-01 |
| 116 | 1.16.2 | **SF6 Update** | 4d | 2009-11-05 | 2009-11-10 | 13.25d |  |  |
| 117 | 1.16.2.1 | Import post snapshot production transports (delta from 10/20 to 10/30) | 0.5d | 2009-08-10 | 2009-08-10 | 13.25d | 0d |  |
| 118 | 1.16.2.2 | Apply kernel update | 0.5d | 2009-08-10 | 2009-08-10 | 13.25d | 0d |  |
| 119 | 1.16.2.3 | Upgrade Oracle db | 0.5d | 2009-08-10 | 2009-08-10 | 13.25d | 0d |  |
| 120 | 1.16.2.4 | Iinstall basis enhancement pack 1 | 1d? | 2009-07-01 | 2009-07-01 | 0d |  |  |
| 121 | 1.16.2.5 | Install ECC enhancement pack 4 | 1d? | 2009-07-01 | 2009-07-01 | 0d |  |  |
| 122 | 1.16.2.6 | Import support packages | 1d | 2009-08-10 | 2009-08-10 | 13.25d | 0d |  |
| 123 | 1.16.2.7 | Apply BSI Tax Factory Update | 0.25d | 2009-08-10 | 2009-08-10 | 13.25d | 0d |  |
| 124 | 1.16.2.8 | Import SF3 transports & post-update DEV transports (to be tested during SI & UAT) | 1d | 2009-08-10 | 2009-08-10 | 13.25d | 0d |  |
| 125 | 1.16.2.9 | Execute trial balance and compare with TB from 10/20 | 0.5d | 2009-08-10 | 2009-08-10 | 13.25d | 0d |  |
| 126 | 1.16.2.10 | Execute action log | 0.5d | 2009-08-10 | 2009-08-10 | 13.25d | 0d |  |
| 127 | 1.16.2.11 | Execute DWH extracts and comparison | 1d | 2009-08-10 | 2009-08-10 | 31.25d |  |  |
| 128 | 1.16.3 | SF7 Update | 1d? | 2009-12-01 | 2009-12-01 | 0d |  | start no earlier than 2009-12-01 |
| 129 | 1.16.4 | SH2 Status Change | 15d? | 2009-12-11 | 2009-12-31 | 0d |  | finish no earlier than 2009-12-31 |
| 130 | 1.16.5 | SH1 Status Change | 15d? | 2009-12-11 | 2009-12-31 | 0d |  | finish no earlier than 2009-12-31 |
| 131 | 1.16.6 | SF5 Status Change | 15d? | 2009-12-11 | 2009-12-31 | 0d |  | finish no earlier than 2009-12-31 |
| 132 | 1.16.7 | PS1 Snapshot for SF5 | 1d? | 2009-12-16 | 2009-12-16 | 0d |  | start no earlier than 2009-12-16 |
| 133 | 1.16.8 | SF5 System refresh & update | 4d? | 2010-01-04 | 2010-01-07 | 0d |  | finish no earlier than 2010-01-07 |
| 134 | 1.16.9 | PS1 Snapshot for SF8 | 1d? | 2009-12-16 | 2009-12-16 | 0d |  | start no earlier than 2009-12-16 |
| 135 | 1.16.10 | SF8 System Refresh & Update | 1d? | 2010-01-28 | 2010-01-28 | 0d |  | start no earlier than 2010-01-28 |
